# BB-01 - prefab beton skelet

Schedule from MS Project, 2003-01-12 to 2003-01-22, status date 2003-01-08.
BAM Nelissen Van Egteren

## Calendars

- ALLEEN WERKDAGEN: Mon-Fri 08:30-12:30, 13:00-17:00; Sat-Sun off. Exceptions (off unless hours are given): 2003-01-11 to 2003-01-12 08:30-12:30, 13:00-17:00, 2003-01-18 to 2003-01-19 08:30-12:30, 13:00-17:00.

## Schedule

| ID | WBS | Task | Type | Duration | Start | Finish | Predecessors | Total slack |
| --- | --- | --- | --- | --- | --- | --- | --- | --- |
| 1 | 1 | **BOVENBOUWFASE** |  | 11d | 2003-01-12 | 2003-01-22 |  | 0d |
| 2 | 1.1 | wanden beg.grond stellen |  | 2d | 2003-01-12 | 2003-01-13 |  | 0d |
| 3 | 1.2 | spouwblad voor+achter stellen |  | 1d | 2003-01-14 | 2003-01-14 | 2SS+2d | 0d |
| 4 | 1.3 | 1e verd. vloerelementen stellen |  | 1d | 2003-01-15 | 2003-01-15 | 3SS+1d | 0d |
| 5 | 1.4 | plaatvoegen aanstorten |  | 1d | 2003-01-16 | 2003-01-16 | 4SS+1d | 0d |
| 6 | 1.5 | wanden 1e verd. stellen |  | 2d | 2003-01-17 | 2003-01-18 | 5SS+1d | 0d |
| 7 | 1.6 | spouwblad voor+achter stellen |  | 1d | 2003-01-19 | 2003-01-19 | 6SS+2d | 0d |
| 8 | 1.7 | zoldervloer elementen stellen |  | 1d | 2003-01-20 | 2003-01-20 | 7SS+1d | 0d |
| 9 | 1.8 | plaatvoegen aanstorten |  | 1d | 2003-01-21 | 2003-01-21 | 8SS+1d | 0d |
| 10 | 1.9 | zoldertoppen elementen stellen |  | 1d | 2003-01-22 | 2003-01-22 | 9SS+1d | 0d |
| 11 | 1.10 | start gevels+daken | milestone | 0d | 2003-01-22 | 2003-01-22 | 10SS+1d | 0d |
